# Gantt_Fortebuso3

Schedule from MS Project, 2013-09-02 to 2014-03-31, costs in €.
.

## Calendars

- Standard: Mon-Fri 09:00-13:00, 14:00-18:00; Sat-Sun off.

## Schedule

| ID | WBS | Task | Duration | Start | Finish | Predecessors | Total slack | Free slack | Constraint | Cost |
| --- | --- | --- | --- | --- | --- | --- | --- | --- | --- | --- |
| 1 | 1 | **Durata dei lavori (giorni lavorativi)** | 150d | 2013-09-02 | 2014-03-31 |  | 0d |  |  |  |
| 2 | 1.1 | Durata complessiva dei lavori | 210ed | 2013-09-02 | 2014-03-31 |  | 0d |  | start no earlier than 2013-09-02 |  |
| 3 | 2 | **A.1) OPERE DI PROTEZIONE ATTIVA E PASSIVA DEL VERSANTE** | 15d | 2013-09-16 | 2013-10-04 |  | 10d |  |  | 133,965.18 |
| 4 | 2.1 | 4.01) Rivestimento pareti rocciose | 5d | 2013-09-16 | 2013-09-20 | 74SS+10d | 10d | 0d | start no earlier than 2013-09-16 | 15,398.62 |
| 5 | 2.2 | 4.02) Consolidamento versante | 10d | 2013-09-23 | 2013-10-04 | 4 | 10d | 0d | start no earlier than 2013-09-23 | 118,566.56 |
| 6 | 3 | **A.2) MOVIMENTI TERRA IN GALLERIA** | 75d | 2013-10-14 | 2014-01-24 |  | 10d |  |  | 2,354,983.16 |
| 7 | 3.1 | 1.01) Scavo in sotterraneo | 75d | 2013-10-14 | 2014-01-24 | 9SS+5d | 10d | 0d | start no earlier than 2013-10-14 | 2,354,983.16 |
| 8 | 4 | **A.3) PRESOSTEGNO DI PRIMA FASE** | 50d | 2013-10-07 | 2013-12-13 |  | 10d |  |  | 910,567.22 |
| 9 | 4.1 | 2.01) Infilaggi, ancoraggi e bullonature | 50d | 2013-10-07 | 2013-12-13 | 5 | 10d | 0d | start no earlier than 2013-10-07 | 533,811.09 |
| 10 | 4.2 | 2.02) Acciaio per tubi, travi di ripartizione, barre, ecc. | 50d | 2013-10-07 | 2013-12-13 | 9SS | 76d |  | start no earlier than 2013-10-07 | 376,756.13 |
| 11 | 5 | **A.4) SOSTEGNO DI PRIMA FASE** | 75d | 2013-10-14 | 2014-01-24 |  | 41d |  |  | 1,567,654.86 |
| 12 | 5.1 | 2.03) Centine | 75d | 2013-10-14 | 2014-01-24 | 7SS | 46d | 0d | finish no earlier than 2014-01-24 | 935,532.96 |
| 13 | 5.2 | 2.04) Calcestruzzi e malte spruzzate | 75d | 2013-10-14 | 2014-01-24 | 12SS | 46d | 0d | finish no earlier than 2014-01-24 | 413,297.2 |
| 14 | 5.3 | 2.07) Acciaio d'armatura, reti e fibre metalliche | 75d | 2013-10-14 | 2014-01-24 | 13SS | 41d | 0d | finish no earlier than 2014-01-24 | 218,824.7 |
| 15 | 6 | **A.5) SOSTEGNO DI SECONDA FASE** | 50d | 2013-11-25 | 2014-01-31 |  | 10d |  |  | 568,811.93 |
| 16 | 6.1 | 2.04) Calcestruzzi e malte spruzzate | 15d | 2014-01-13 | 2014-01-31 | 14FS-10d | 41d |  | start no earlier than 2014-01-13 | 448,270.62 |
| 17 | 6.2 | 2.05) Cementi armati | 25d | 2013-11-25 | 2013-12-27 | 7SS+30d | 10d | 0d | start no earlier than 2013-11-25 | 67,550.71 |
| 18 | 6.3 | 2.07) Acciaio d'armatura, reti e fibre metalliche | 25d | 2013-11-25 | 2013-12-27 | 17SS | 66d |  | finish no earlier than 2013-12-27 | 51,201.86 |
| 19 | 6.4 | 2.09) Casseri | 25d | 2013-11-25 | 2013-12-27 | 17SS | 66d |  | finish no earlier than 2013-12-27 | 1,788.74 |
| 20 | 7 | **A.6) MOVIMENTI TERRA E DEMOLIZIONI ALL'APERTO** | 45d | 2013-12-30 | 2014-02-28 |  | 10d |  |  | 15,846.89 |
| 21 | 7.1 | 1.02) Scavi, demolizioni, compattazioni e rilevati | 45d | 2013-12-30 | 2014-02-28 | 17 | 10d | 0d | start no earlier than 2013-12-30 | 15,846.89 |
| 22 | 8 | **A.7) REGIMAZIONE ACQUE DI PIATTAFORMA** | 68d | 2013-11-18 | 2014-02-19 |  | 28d |  |  | 187,507.13 |
| 23 | 8.1 | 1.02) Scavi, demolizioni, compattazioni e rilevati | 68d | 2013-11-18 | 2014-02-19 | 17SS-5d | 28d | 0d | start no earlier than 2013-11-18 | 8,340.27 |
| 24 | 8.2 | 2.06) Cementi armati | 15d | 2014-01-27 | 2014-02-14 |  | 4d | 0d | start no earlier than 2014-01-27 | 6,571.39 |
| 25 | 8.3 | 2.08) Acciaio d'armatura, reti e fibre metalliche | 15d | 2014-01-27 | 2014-02-14 |  | 31d |  | start no earlier than 2014-01-27 | 8,268.98 |
| 26 | 8.4 | 2.10) Casseri | 15d | 2014-01-27 | 2014-02-14 |  | 31d |  | start no earlier than 2014-01-27 | 4,724.73 |
| 27 | 8.5 | 3.01) Tubazioni e manufatti in ghisa | 62d | 2013-11-21 | 2014-02-14 | 23SS+3d | 31d |  | start no earlier than 2013-11-21 | 93,246.16 |
| 28 | 8.6 | 3.02) Pozzetti e manufatti in calcestruzzo | 62d | 2013-11-21 | 2014-02-14 | 23SS+3d | 31d |  | start no earlier than 2013-11-21 | 59,513.85 |
| 29 | 8.7 | 3.03) Impermeabilizzazioni | 3d | 2014-02-17 | 2014-02-19 | 24 | 28d |  | start no earlier than 2014-02-17 | 6,841.75 |

| ID | WBS | Task | Duration | Start | Finish | Predecessors | Total slack | Free slack | Constraint | Cost |
| --- | --- | --- | --- | --- | --- | --- | --- | --- | --- | --- |
| 30 | 9 | **A.8) SOVRASTRUTTURA STRADALE** | 21d | 2014-02-17 | 2014-03-17 |  | 10d |  |  | 302,495.07 |
| 31 | 9.1 | 5.01) Pavimentazioni: preparazione del fondo | 15d | 2014-02-17 | 2014-03-07 | 21FS-10d | 10d | 0d | start no earlier than 2014-02-17 | 65,651.83 |
| 32 | 9.2 | 5.02) Pavimentazioni in conglomerato bituminoso | 6d | 2014-03-10 | 2014-03-17 | 31 | 10d |  | start no earlier than 2014-03-10 | 236,843.24 |
| 33 | 10 | **A.9) LAVORI DI COMPLETAMENTO E ACCESSORI** | 27d | 2014-02-17 | 2014-03-25 |  | 4d |  |  | 145,836.51 |
| 34 | 10.1 | 1.02) Scavi, demolizioni, compattazioni e rilevati | 3d | 2014-02-24 | 2014-02-26 | 31SS+5d | 16d | 0d | start no earlier than 2014-02-24 | 1,534.26 |
| 35 | 10.2 | 2.06) Cementi armati | 7d | 2014-02-27 | 2014-03-07 | 34 | 16d | 0d | start no earlier than 2014-02-27 | 6,255.92 |
| 36 | 10.3 | 2.08) Acciaio d'armatura, reti e fibre metalliche | 7d | 2014-02-27 | 2014-03-07 | 35SS | 16d |  | start no earlier than 2014-02-27 | 5,629.91 |
| 37 | 10.4 | 2.10) Casseri | 7d | 2014-02-27 | 2014-03-07 | 35SS | 16d |  | start no earlier than 2014-02-27 | 1,336.88 |
| 38 | 10.5 | 5.03) Barriere stradali ed accessori | 25d | 2014-02-17 | 2014-03-21 | 24 | 4d | 0d | start no earlier than 2014-02-17 | 128,884 |
| 39 | 10.6 | 5.04) Segnaletica orizzontale e verticale | 7d | 2014-03-17 | 2014-03-25 | 38FS-5d | 4d |  | start no earlier than 2014-03-17 | 2,195.54 |
| 40 | 11 | **A.10) SOTTOSERVIZI (ACQUEDOTTO E FOGNATURA)** | 62d | 2013-11-21 | 2014-02-14 |  | 31d |  |  | 197,302.63 |
| 41 | 11.1 | 1.01) Scavo in sotterraneo | 62d | 2013-11-21 | 2014-02-14 |  | 31d |  | start no earlier than 2013-11-21 | 96,836.71 |
| 42 | 11.2 | 1.02) Scavi, demolizioni, compattazioni e rilevati | 62d | 2013-11-21 | 2014-02-14 |  | 31d |  | start no earlier than 2013-11-21 | 668.9 |
| 43 | 11.3 | 3.01) Tubazioni e manufatti in ghisa | 62d | 2013-11-21 | 2014-02-14 |  | 31d |  | start no earlier than 2013-11-21 | 99,797.02 |
| 44 | 12 | **A.11) SOTTOSERVIZI (PREDISPOSIZIONE PER FIBRA OTTICA)** | 62d | 2013-11-21 | 2014-02-14 |  | 31d |  |  | 58,779.48 |
| 45 | 12.1 | 1.01) Scavo in sotterraneo | 62d | 2013-11-21 | 2014-02-14 |  | 31d |  | start no earlier than 2013-11-21 | 48,418.36 |
| 46 | 12.2 | 3.01) Tubazioni e manufatti in ghisa | 62d | 2013-11-21 | 2014-02-14 |  | 31d |  | start no earlier than 2013-11-21 | 10,361.12 |
| 47 | 13 | **Oneri sicurezza** | 150d | 2013-09-02 | 2014-03-31 |  | 0d |  |  | 166,437.8 |
| 48 | 13.1 | **A.1) OPERE DI PROTEZIONE ATTIVA E PASSIVA DEL VERSANTE** | 5d | 2013-09-18 | 2013-09-24 |  | 134d |  |  | 874.8 |
| 49 | 13.1.1 | 6,06)Procedure di sicurezza | 5d | 2013-09-18 | 2013-09-24 |  | 134d |  | start no earlier than 2013-09-18 | 874.8 |
| 50 | 13.2 | **A.2) MOVIMENTI TERRA IN GALLERIA** | 80d | 2013-10-07 | 2014-01-24 |  | 46d |  |  | 98,978.35 |
| 51 | 13.2.1 | 6,01) Cantierizzazione | 5d | 2013-10-07 | 2013-10-11 |  | 121d |  | start no earlier than 2013-10-04 | 19,899.35 |
| 52 | 13.2.2 | 6,02) Cantierizzazione noleggi | 75d | 2013-10-14 | 2014-01-24 |  | 46d |  | start no earlier than 2013-10-14 | 70,859 |
| 53 | 13.2.3 | 6,05) Impianti | 5d | 2013-10-07 | 2013-10-11 |  | 121d |  | start no earlier than 2013-10-07 | 1,500 |
| 54 | 13.2.4 | 6,06) Procedure di sicurezza | 75d | 2013-10-14 | 2014-01-24 |  | 46d |  | start no earlier than 2013-10-14 | 6,720 |

| ID | WBS | Task | Duration | Start | Finish | Predecessors | Total slack | Constraint | Cost |
| --- | --- | --- | --- | --- | --- | --- | --- | --- | --- |
| 55 | 13.3 | **A.3) PRESOSTEGNO DI PRIMA FASE** | 5d | 2013-10-14 | 2013-10-18 |  | 116d |  | 4,906.21 |
| 56 | 13.3.1 | 6,01) Cantierizzazione | 2d | 2013-10-14 | 2013-10-15 |  | 119d | start no earlier than 2013-10-14 | 86.41 |
| 57 | 13.3.2 | 6,05) Impianti | 5d | 2013-10-14 | 2013-10-18 |  | 116d | start no earlier than 2013-10-14 | 4,819.8 |
| 58 | 13.4 | **A.4) SOSTEGNO DI PRIMA FASE** | 75d | 2013-10-14 | 2014-01-24 |  | 46d |  | 14,673 |
| 59 | 13.4.1 | 6,06) Procedure di sicurezza | 75d | 2013-10-14 | 2014-01-24 |  | 46d | start no earlier than 2013-10-14 | 9,928 |
| 60 | 13.4.2 | **A.5) SOSTEGNO DI SECONDA FASE** | 25d | 2013-11-25 | 2013-12-27 |  | 66d |  | 4,745 |
| 61 | 13.4.2.1 | 6,06) Procedure di sicurezza | 25d | 2013-11-25 | 2013-12-27 |  | 66d | start no earlier than 2013-11-25 | 4,745 |
| 62 | 13.5 | **A.6) MOVIMENTI TERRA E DEMOLIZIONI ALL'APERTO** | 45d | 2013-12-30 | 2014-02-28 |  | 21d |  | 6,240.66 |
| 63 | 13.5.1 | 6,01) Cantierizzazione | 5d | 2013-12-30 | 2014-01-03 |  | 61d | start no earlier than 2013-12-30 | 17.16 |
| 64 | 13.5.2 | 6,06) Procedure di sicurezza | 45d | 2013-12-30 | 2014-02-28 |  | 21d | start no earlier than 2013-12-30 | 6,223.5 |
| 65 | 13.6 | **A.7) REGIMAZIONE ACQUE DI PIATTAFORMA** | 15d | 2014-01-27 | 2014-02-14 |  | 31d |  | 957.2 |
| 66 | 13.6.1 | 6,03) Ponteggi | 15d | 2014-01-27 | 2014-02-14 |  | 31d | start no earlier than 2014-01-27 | 697.2 |
| 67 | 13.6.2 | 6,06) Procedure di sicurezza | 15d | 2014-01-27 | 2014-02-14 |  | 31d | start no earlier than 2014-01-27 | 260 |
| 68 | 13.7 | **A.9) LAVORI DI COMPLETAMENTO E ACCESSORI** | 3d | 2014-02-17 | 2014-02-19 |  | 28d |  | 2,573 |
| 69 | 13.7.1 | 6,03) Ponteggi | 3d | 2014-02-17 | 2014-02-19 |  | 28d | start no earlier than 2014-02-17 | 2,573 |
| 70 | 13.8 | **A.10) SOTTOSERVIZI (ACQUEDOTTO E FOGNATURA)** | 37d | 2013-11-21 | 2014-01-10 |  | 56d |  | 2,410.27 |
| 71 | 13.8.1 | 6,01) Cantierizzazione | 7d | 2013-11-21 | 2013-11-29 |  | 86d | start no earlier than 2013-11-21 | 103.57 |
| 72 | 13.8.2 | 6,04) Segnaletica | 37d | 2013-11-21 | 2014-01-10 |  | 56d | start no earlier than 2013-11-21 | 2,306.7 |
| 73 | 13.9 | **B1) LOGISTICA DI CANTIERE** | 150d | 2013-09-02 | 2014-03-31 |  | 0d |  | 34,824.31 |
| 74 | 13.9.1 | 6,01) Cantierizzazione | 210ed | 2013-09-02 | 2014-03-31 |  | 0d |  | 21,783.74 |
| 75 | 13.9.2 | 6,02) Cantierizzazione noleggi | 150d | 2013-09-02 | 2014-03-28 | 74SS | 0d |  | 9,996.88 |
| 76 | 13.9.3 | 6,04) Segnaletica | 10d | 2013-09-09 | 2013-09-20 | 74SS+5d | 136d | start no earlier than 2013-09-09 | 3,043.69 |
| 77 | 13.9.4 | Senso unico alternato | 100ed | 2013-09-02 | 2013-12-11 |  | 330d |  |  |
| 78 | 13.9.5 | Chiusura strada | 110ed | 2013-12-11 | 2014-03-31 |  | 0d | start no earlier than 2013-12-11 |  |
